# SUBPROYECTO A4 - PAMPA DEL TORO

How a schedule from Primavera P6 changed from version to version. A marks actual dates.

## Version 1 (data date 2022-10-01, saved 2022-09-29, file Cronograma-SUBPROYECTO A4-PAMPA DEL TORO.xer)

| ID | WBS | Task | Duration | Start | Finish | Predecessors | Total float |
| --- | --- | --- | --- | --- | --- | --- | --- |
|  | 1 | **HITOS DEL PROYECTO** |  | 2022-10-01 | 2022-12-09 |  |  |
| HP.010 |  | INICIO DE DE OBRA - ACCESO AL SITIO (Después de la firma del Acta de Entrega de Terreno) | 0d | 2022-10-01 | 2022-10-01 |  | 0d |
| HP.020 |  | INICIO DE EXCAVACIÓN | 0d | 2022-11-08 | 2022-11-08 | D.03.010 SS | 32d |
| HP.030 |  | INICIO DE RELLENO DE DIQUE | 0d | 2022-11-12 | 2022-11-12 | D.04.030 SS | 28d |
| HP.040 |  | CULMINACIÓN DE OBRAS | 0d | 2022-12-09 | 2022-12-09 | PCO.010, D.05.110, PCO.040, TP.050, OP.030 | 0d |
|  | 2 | **TRABAJOS PRELIMINARES** |  | 2022-10-01 | 2022-12-09 |  |  |
| TP.010 |  | MOVILIZACIÓN DE RECURSOS (PERSONAL, EQUIPOS, MATERIALES) | 20d | 2022-10-01 | 2022-10-20 | HP.010 | 0d |
| TP.020 |  | ELABORACIÓN DE DOCUMENTOS ENTRE SUBCONTRATISTA Y OHLA | 15d | 2022-10-01 | 2022-10-15 | HP.010 | 0d |
| TP.030 |  | APROBACIÓN DE DOCUMENTOS ENTRE SUBCONTRATISTA Y OHLA | 5d | 2022-10-16 | 2022-10-20 | TP.020 | 0d |
| TP.050 |  | TOPOGRAFIA Y GEOREFRENCIACIÓN DE OBRA | 50d | 2022-10-21 | 2022-12-09 | TP.010 | 0d |
|  | 3 | **OBRAS PRELIMINARES** |  | 2022-10-26 | 2022-12-09 |  |  |
| OP.030 |  | MANTENIMIENTO DE TRANSITO Y SEGURIDAD VIAL | 45d | 2022-10-26 | 2022-12-09 | MV.020 | 0d |
| OP.010 |  | INSTALACIONES PROVISIONALES PARA LA OBRA | 5d | 2022-11-05 | 2022-11-09 | MV.040 SS+5d | 30d |
| OP.020 |  | CARTEL DE IDENTIFICACIÓN DE OBRA 4.8 m x 3.60 m | 1d | 2022-11-07 | 2022-11-07 | OP.010 SS+2d | 32d |
|  | C | **CONSTRUCCIÓN** |  | 2022-10-21 | 2022-12-09 |  |  |
|  | 70 | **OBRAS EXTERIORES** |  | 2022-10-21 | 2022-12-09 |  |  |
|  | 02 | **CARRETERAS, CAMINOS, PAVIMENTOS** |  | 2022-10-21 | 2022-11-10 |  |  |
|  | 01 | **MEJORAMIENTO DE VIAS EXISTENTES** |  | 2022-10-21 | 2022-11-10 |  |  |
|  | 01 | **MOVIMIENTO DE TIERRAS** |  | 2022-10-21 | 2022-11-03 |  |  |
| MV.010 |  | ROCE Y LIMPIEZA DE MALEZA | 5d | 2022-10-21 | 2022-10-25 | TP.010, TP.030 | 0d |
| MV.020 |  | MEJORAMIENTO DE VIAS EXISTENTES - VIA DE ACCESO A DME 13 | 3d | 2022-10-23 | 2022-10-25 | MV.010 SS+2d | 0d |
| MV.030 |  | MEJORAMIENTO DE VIAS EXISTENTES - VIA DE ACCESO A DIQUE MI | 5d | 2022-10-26 | 2022-10-30 | MV.020 | 0d |
| MV.040 |  | MEJORAMIENTO DE VIAS EXISTENTES - VIA DE ACCESO A DIQUE MD | 4d | 2022-10-31 | 2022-11-03 | MV.030 | 0d |
|  | 02 | **REPOSICIÓN DE ESTRUCTURAS** |  | 2022-10-26 | 2022-11-10 |  |  |
| RE.010 |  | DEMOLICIÓN DE ESTRUCTURAS EXISTENTES | 4d | 2022-10-26 | 2022-10-29 | MV.020 | 29d |
| RE.020 |  | REPOSICIÓN DE PASE DE AGUA TUBERÍA HDPE CORRUGADA Ø=24" | 4d | 2022-10-30 | 2022-11-02 | RE.010 | 29d |
| RE.040 |  | REPOSICIÓN DE PASE DE AGUA TUBERÍA HDPE CORRUGADA Ø=36" | 4d | 2022-10-30 | 2022-11-02 | RE.020 SS | 29d |
| RE.060 |  | MONTAJE DE LOSA CONCRETO 1.6mx1.0mx0.20m EN PASE DE AGUA | 2d | 2022-10-31 | 2022-11-01 | MV.030 | 5d |
| RE.030 |  | ESTRUCTURA DE CONCRETO 175 Kg/cm2 DE CABEZAL ENTRADA Y SALIDA DE TUB. HDPE CORRUGADA Ø=24" | 8d | 2022-11-03 | 2022-11-10 | RE.020 | 29d |
| RE.050 |  | ESTRUCTURA DE CONCRETO 175 Kg/cm2 DE CABEZAL ENTRADA Y SALIDA DE TUB. HDPE CORRUGADA Ø=36" | 8d | 2022-11-03 | 2022-11-10 | RE.040, RE.030 SS | 29d |
|  | 00 | **GENERAL** |  | 2022-10-26 | 2022-12-09 |  |  |
|  | 03 | **PROGRAMA DE CIERRE DE OBRA** |  | 2022-10-26 | 2022-12-09 |  |  |
| PCO.010 |  | RESTAURACIÓN DE ÁREAS DE INSTALACIONES PROVISIONALES | 3d | 2022-12-07 | 2022-12-09 | RC.040, D.05.110, PLR-01-050, I-03.090 | 0d |
|  | 2 | **ACONDICIONAMIENTO DE DEPÓSITOS DE MATERIALES EXCEDENTES** |  | 2022-10-26 | 2022-12-01 |  |  |
| PCO.020 |  | RETIRO Y ALMACENAMIENTO DE TOPSOIL DEL DME | 4d | 2022-10-26 | 2022-10-29 | MV.020 | 25d |
| PCO.030 |  | ACONDICIONAMIENTO DE MATERIAL EN BOTADERO | 16d | 2022-11-08 | 2022-11-23 | D.03.010 SS, PCO.020 | 16d |
| PCO.040 |  | COLOCACIÓN DE CAPA SUPERFICIAL DEL DME | 4d | 2022-11-28 | 2022-12-01 | D.03.015, D.05.020, D.05.040, RC.020 | 8d |
|  | 14 | **REFUERZO DE RIBERA DEL RIO** |  | 2022-11-04 | 2022-12-06 |  |  |
|  | 5 | **PROTECCIÓN DEL CAUCE CON ENROCADO (A4-PT-PLR-01)-AGUAS ABAJO** |  | 2022-11-04 | 2022-11-11 |  |  |
| PLR-01-010 |  | DESBROCE Y LIMPIEZA EN ZONA NO BOSCOSA | 1d | 2022-11-04 | 2022-11-04 | MV.040, RE.060 | 3d |
| PLR-01-020 |  | EXCAVACIÓN EN MATERIAL SUELTO CON EQUIPO | 2d | 2022-11-05 | 2022-11-06 | PLR-01-010 | 3d |
| PLR-01-030 |  | PERFILADO Y COMPACTACIÓN CON EQUIPO DE FONDO DE EXCAVACIÓN | 2d | 2022-11-06 | 2022-11-07 | PLR-01-020 FF+1d | 3d |
| PLR-01-040 |  | TRANSPORTE DE ROCA | 5d | 2022-11-06 | 2022-11-10 | PLR-01-030 SS | 5d |
| PLR-01-050 |  | COLOCACIÓN DE ROCA EN CAUCE | 5d | 2022-11-07 | 2022-11-11 | PLR-01-040 SS+1d | 5d |
|  | 10 | **PROTECCION DE TALUDES (A4-PT-D-03)** |  | 2022-11-08 | 2022-11-19 |  |  |
| D.03.010 |  | DESBROCE Y LIMPIEZA EN ZONA NO BOSCOSA | 1d | 2022-11-08 | 2022-11-08 | PLR-01-030 | 3d |
| D.03.015 |  | TRANSPORTE DE MATERIAL EXCEDENTE | 1d | 2022-11-08 | 2022-11-08 | D.03.010 SS | 27d |
| D.03.020 |  | RELLENO ESTRUCTURAL CON MATERIAL PROPIO EN TALUD EXISTENTE | 2d | 2022-11-09 | 2022-11-10 | D.03.010 | 3d |
| D.03.030 |  | EXCAVACIÓN EN TERRENO NATURAL CON EQUIPO | 1d | 2022-11-11 | 2022-11-11 | D.03.020 | 3d |
| D.03.040 |  | PERFILADO Y COMPACTACIÓN EN ZONA DE CORTE | 1d | 2022-11-12 | 2022-11-12 | D.03.030 | 3d |
| D.03.060 |  | COLOCACIÓN DE GEOTEXTIL NO TEJIDO 400 gr/m2 | 1d | 2022-11-13 | 2022-11-13 | D.03.040 | 3d |
| D.03.070 |  | TRANSPORTE DE ROCA | 6d | 2022-11-13 | 2022-11-18 | D.03.060 SS | 3d |
| D.03.080 |  | COLOCACIÓN Y ACOMODO DE ROCA EN UÑA DEL DIQUE | 2d | 2022-11-14 | 2022-11-15 | D.03.070 SS+1d, PLR-01-050 | 3d |
| D.03.090 |  | COLOCACIÓN Y ACOMODO DE ROCA EN TALUD DEL DIQUE | 4d | 2022-11-16 | 2022-11-19 | D.03.080 | 3d |
|  | 1 | **PROTECCION DE TALUDES (A4-PT-I-02)** |  | 2022-11-13 | 2022-11-25 |  |  |
| I-02.010 |  | DESBROCE Y LIMPIEZA EN ZONA NO BOSCOSA | 1d | 2022-11-13 | 2022-11-13 | D.03.040 | 3d |
| I-02.020 |  | TRANSPORTE DE MATERIAL EXCEDENTE | 1d | 2022-11-13 | 2022-11-13 | I-02.010 SS | 26d |
| I-02.030 |  | RELLENO ESTRUCTURAL CON MATERIAL PROPIO EN TALUD EXISTENTE | 2d | 2022-11-14 | 2022-11-15 | I-02.010 | 3d |
| I-02.040 |  | EXCAVACIÓN EN TERRENO NATURAL CON EQUIPO | 2d | 2022-11-16 | 2022-11-17 | I-02.030 | 3d |
| I-02.050 |  | PERFILADO Y COMPACTACIÓN EN ZONA DE CORTE | 2d | 2022-11-17 | 2022-11-18 | I-02.040 FF+1d | 3d |
| I-02.060 |  | COLOCACIÓN DE GEOTEXTIL NO TEJIDO 400 gr/m2 | 2d | 2022-11-19 | 2022-11-20 | I-02.050 | 3d |
| I-02.070 |  | TRANSPORTE DE ROCA | 6d | 2022-11-19 | 2022-11-24 | I-02.060 SS | 3d |
| I-02.080 |  | COLOCACIÓN Y ACOMODO DE ROCA EN UÑA DEL DIQUE | 2d | 2022-11-20 | 2022-11-21 | I-02.070 SS+1d, D.03.090 | 3d |
| I-02.090 |  | COLOCACIÓN Y ACOMODO DE ROCA EN TALUD DEL DIQUE | 4d | 2022-11-22 | 2022-11-25 | I-02.080 | 3d |
|  | 2 | **PROTECCION DE TALUDES (A4-PT-I-03)** |  | 2022-11-19 | 2022-12-03 |  |  |
| I-03.010 |  | DESBROCE Y LIMPIEZA EN ZONA NO BOSCOSA | 1d | 2022-11-19 | 2022-11-19 | D.04.050, I-02.050 | 4d |
| I-03.012 |  | TRANSPORTE DE MATERIAL EXCEDENTE | 1d | 2022-11-19 | 2022-11-19 | I-03.010 SS | 20d |
| I-03.020 |  | RELLENO ESTRUCTURAL CON MATERIAL PROPIO EN TALUD EXISTENTE | 2d | 2022-11-20 | 2022-11-21 | I-03.010 | 4d |
| I-03.030 |  | EXCAVACIÓN EN TERRENO NATURAL CON EQUIPO | 1d | 2022-11-22 | 2022-11-22 | I-03.020 | 4d |
| I-03.040 |  | PERFILADO Y COMPACTACIÓN EN ZONA DE CORTE | 1d | 2022-11-23 | 2022-11-23 | I-03.030 | 4d |

| ID | WBS | Task | Duration | Start | Finish | Predecessors | Total float |
| --- | --- | --- | --- | --- | --- | --- | --- |
| I-03.060 |  | COLOCACIÓN DE GEOTEXTIL NO TEJIDO 400 gr/m2 | 2d | 2022-11-24 | 2022-11-25 | I-03.040 | 4d |
| I-03.070 |  | TRANSPORTE DE ROCA | 8d | 2022-11-24 | 2022-12-01 | I-03.060 SS | 4d |
| I-03.080 |  | COLOCACIÓN Y ACOMODO DE ROCA EN UÑA DEL DIQUE | 4d | 2022-11-26 | 2022-11-29 | I-03.070 SS+1d, I-02.090 | 3d |
| I-03.090 |  | COLOCACIÓN Y ACOMODO DE ROCA EN TALUD DEL DIQUE | 4d | 2022-11-30 | 2022-12-03 | I-03.080 | 3d |
|  | 3 | **PROTECCIÓN DEL CAUCE CON ENROCADO (A4-PT-PLR-01)-AGUAS ARRIBA** |  | 2022-11-04 | 2022-11-13 |  |  |
| PLR-01-060 |  | DESBROCE Y LIMPIEZA EN ZONA NO BOSCOSA | 2d | 2022-11-04 | 2022-11-05 | MV.040 | 0d |
| PLR-01-070 |  | EXCAVACIÓN EN MATERIAL SUELTO CON EQUIPO | 3d | 2022-11-06 | 2022-11-08 | PLR-01-060 | 0d |
| PLR-01-080 |  | PERFILADO Y COMPACTACIÓN CON EQUIPO DE FONDO DE EXCAVACIÓN | 2d | 2022-11-08 | 2022-11-09 | PLR-01-070 FF+1d | 0d |
| PLR-01-090 |  | TRANSPORTE DE ROCA | 5d | 2022-11-08 | 2022-11-12 | PLR-01-080 SS | 4d |
| PLR-01-100 |  | COLOCACIÓN DE ROCA EN CAUCE | 5d | 2022-11-09 | 2022-11-13 | PLR-01-090 SS+1d | 4d |
|  | 9 | **DIQUE DE TIERRA COMPACTADA (A4-PT- D-04)** |  | 2022-11-10 | 2022-11-24 |  |  |
| D.04.010 |  | DESBROCE Y LIMPIEZA EN ZONA NO BOSCOSA | 2d | 2022-11-10 | 2022-11-11 | PLR-01-080 | 0d |
| D.04.020 |  | TRANSPORTE DE MATERIAL EXCEDENTE | 2d | 2022-11-10 | 2022-11-11 | D.04.010 SS | 28d |
| D.04.030 |  | CONFORMACION DE CUERPO DE DIQUE | 3d | 2022-11-12 | 2022-11-14 | D.04.010 | 0d |
| D.04.040 |  | EXCAVACIÓN EN TERRENO NATURAL CON EQUIPO | 2d | 2022-11-14 | 2022-11-15 | D.04.030 FF+1d | 0d |
| D.04.050 |  | PERFILADO Y COMPACTACIÓN EN ZONA DE CORTE | 2d | 2022-11-15 | 2022-11-16 | D.04.040 FF+1d | 0d |
| D.04.060 |  | COLOCACIÓN DE GEOTEXTIL NO TEJIDO 400 gr/m2 | 2d | 2022-11-17 | 2022-11-18 | D.04.050 | 0d |
| D.04.070 |  | TRANSPORTE DE ROCA | 5d | 2022-11-17 | 2022-11-21 | D.04.060 SS | 0d |
| D.04.080 |  | COLOCACIÓN Y ACOMODO DE ROCA EN UÑA DEL DIQUE | 2d | 2022-11-18 | 2022-11-19 | D.04.070 SS+1d, PLR-01-100 | 0d |
| D.04.090 |  | COLOCACIÓN Y ACOMODO DE ROCA EN TALUD DEL DIQUE | 4d | 2022-11-20 | 2022-11-23 | D.04.080 | 0d |
| D.04.100 |  | CONFORMACIÓN DE MATERIAL GRANULAR EN CORONA DE DIQUE (e=0.30 m) | 1d | 2022-11-24 | 2022-11-24 | D.04.090 | 15d |
|  | 4 | **DIQUE DE TIERRA COMPACTADA (A4-PT- D-05)** |  | 2022-11-16 | 2022-12-06 |  |  |
| D.05.010 |  | DESBROCE Y LIMPIEZA EN ZONA NO BOSCOSA | 2d | 2022-11-16 | 2022-11-17 | D.04.040 | 0d |
| D.05.020 |  | TRANSPORTE DE MATERIAL EXCEDENTE | 2d | 2022-11-16 | 2022-11-17 | D.05.010 SS | 18d |
| D.05.030 |  | CONFORMACION DE CUERPO DE DIQUE | 5d | 2022-11-18 | 2022-11-22 | D.05.010 | 0d |
| D.05.040 |  | EXCAVACIÓN EN TERRENO NATURAL CON EQUIPO | 2d | 2022-11-22 | 2022-11-23 | D.05.030 FF+1d | 0d |
| D.05.050 |  | PERFILADO Y COMPACTACIÓN EN ZONA DE CORTE | 3d | 2022-11-22 | 2022-11-24 | D.05.040 FF+1d | 0d |
| D.05.070 |  | COLOCACIÓN DE GEOTEXTIL NO TEJIDO 400 gr/m2 | 3d | 2022-11-23 | 2022-11-25 | D.05.050 SS+1d | 0d |
| D.05.080 |  | TRANSPORTE DE ROCA | 11d | 2022-11-23 | 2022-12-03 | D.05.070 SS | 0d |
| D.05.090 |  | COLOCACIÓN Y ACOMODO DE ROCA EN UÑA DEL DIQUE | 4d | 2022-11-24 | 2022-11-27 | D.05.080 SS+1d, D.04.090 | 0d |
| D.05.100 |  | COLOCACIÓN Y ACOMODO DE ROCA EN TALUD DEL DIQUE | 7d | 2022-11-28 | 2022-12-04 | D.05.090 | 0d |
| D.05.110 |  | CONFORMACIÓN DE MATERIAL GRANULAR EN CORONA DE DIQUE (e=0.30 m) | 2d | 2022-12-05 | 2022-12-06 | D.05.100 | 0d |
|  | 7 | **REPOSICIÓN DE CAMINO DE ACCESO (A4-RC-1)** |  | 2022-11-25 | 2022-11-30 |  |  |
| RC.010 |  | DESBROCE Y LIMPIEZA EN ZONA NO BOSCOSA | 1d | 2022-11-25 | 2022-11-25 | D.05.050 | 6d |
| RC.020 |  | EXCAVACIÓN EN MATERIAL SUELTO CON EQUIPO | 2d | 2022-11-26 | 2022-11-27 | RC.010 | 6d |
| RC.030 |  | PERFILADO Y COMPACTACIÓN EN ZONA DE CORTE | 2d | 2022-11-28 | 2022-11-29 | RC.020 | 6d |
| RC.040 |  | MATERIAL AFIRMADO e=25 cm | 1d | 2022-11-30 | 2022-11-30 | RC.030 | 6d |

## Version 2 (data date 2022-11-01, saved 2022-10-17, file Cronograma-SUBPROYECTO A4-PAMPA DEL TORO.xer)

Last finish 2022-12-09 → 2022-12-30 (+21d).

Changed:

| ID | Task | Start | Finish | Duration | Total float |
| --- | --- | --- | --- | --- | --- |
| 1 | **HITOS DEL PROYECTO** | 2022-10-01 → 2022-11-01 (+31d) | 2022-12-09 → 2022-12-30 (+21d) |  |  |
| HP.010 | INICIO DE DE OBRA - ACCESO AL SITIO (Después de la firma del Acta de Entrega de Terreno) | 2022-10-01 → 2022-11-01 (+31d) | 2022-10-01 → 2022-11-01 (+31d) |  |  |
| HP.020 | INICIO DE EXCAVACIÓN | 2022-11-08 → 2022-12-01 (+23d) | 2022-11-08 → 2022-12-01 (+23d) |  | 32d → 30d |
| HP.030 | INICIO DE RELLENO DE DIQUE | 2022-11-12 → 2022-12-05 (+23d) | 2022-11-12 → 2022-12-05 (+23d) |  | 28d → 26d |
| HP.040 | CULMINACIÓN DE OBRAS | 2022-12-09 → 2022-12-30 (+21d) | 2022-12-09 → 2022-12-30 (+21d) |  |  |
| 2 | **TRABAJOS PRELIMINARES** | 2022-10-01 → 2022-11-01 (+31d) | 2022-12-09 → 2022-12-30 (+21d) |  |  |
| TP.010 | MOVILIZACIÓN DE RECURSOS (PERSONAL, EQUIPOS, MATERIALES) | 2022-10-01 → 2022-11-01 (+31d) | 2022-10-20 → 2022-11-15 (+26d) | 20d → 15d |  |
| TP.020 | ELABORACIÓN DE DOCUMENTOS ENTRE SUBCONTRATISTA Y OHLA | 2022-10-01 → 2022-11-01 (+31d) | 2022-10-15 → 2022-11-10 (+26d) | 15d → 10d |  |
| TP.030 | APROBACIÓN DE DOCUMENTOS ENTRE SUBCONTRATISTA Y OHLA | 2022-10-16 → 2022-11-11 (+26d) | 2022-10-20 → 2022-11-15 (+26d) |  |  |
| TP.050 | TOPOGRAFIA Y GEOREFRENCIACIÓN DE OBRA | 2022-10-21 → 2022-11-16 (+26d) | 2022-12-09 → 2022-12-30 (+21d) | 50d → 45d |  |
| 3 | **OBRAS PRELIMINARES** | 2022-10-26 → 2022-11-21 (+26d) | 2022-12-09 → 2022-12-25 (+16d) |  |  |
| OP.030 | MANTENIMIENTO DE TRANSITO Y SEGURIDAD VIAL | 2022-10-26 → 2022-11-21 (+26d) | 2022-12-09 → 2022-12-25 (+16d) | 45d → 35d | 0d → 5d |
| OP.010 | INSTALACIONES PROVISIONALES PARA LA OBRA | 2022-11-05 → 2022-11-29 (+24d) | 2022-11-09 → 2022-12-03 (+24d) |  | 30d → 27d |
| OP.020 | CARTEL DE IDENTIFICACIÓN DE OBRA 4.8 m x 3.60 m | 2022-11-07 → 2022-12-01 (+24d) | 2022-11-07 → 2022-12-01 (+24d) |  | 32d → 29d |
| C | **CONSTRUCCIÓN** | 2022-10-21 → 2022-11-16 (+26d) | 2022-12-09 → 2022-12-30 (+21d) |  |  |
| 70 | **OBRAS EXTERIORES** | 2022-10-21 → 2022-11-16 (+26d) | 2022-12-09 → 2022-12-30 (+21d) |  |  |
| 02 | **CARRETERAS, CAMINOS, PAVIMENTOS** | 2022-10-21 → 2022-11-16 (+26d) | 2022-11-10 → 2022-12-06 (+26d) |  |  |
| 01 | **MEJORAMIENTO DE VIAS EXISTENTES** | 2022-10-21 → 2022-11-16 (+26d) | 2022-11-10 → 2022-12-06 (+26d) |  |  |
| 01 | **MOVIMIENTO DE TIERRAS** | 2022-10-21 → 2022-11-16 (+26d) | 2022-11-03 → 2022-11-26 (+23d) |  |  |
| MV.010 | ROCE Y LIMPIEZA DE MALEZA | 2022-10-21 → 2022-11-16 (+26d) | 2022-10-25 → 2022-11-20 (+26d) |  |  |
| MV.020 | MEJORAMIENTO DE VIAS EXISTENTES - VIA DE ACCESO A DME 13 | 2022-10-23 → 2022-11-18 (+26d) | 2022-10-25 → 2022-11-20 (+26d) |  |  |
| MV.030 | MEJORAMIENTO DE VIAS EXISTENTES - VIA DE ACCESO A DIQUE MI | 2022-10-26 → 2022-11-21 (+26d) | 2022-10-30 → 2022-11-23 (+24d) | 5d → 3d |  |
| MV.040 | MEJORAMIENTO DE VIAS EXISTENTES - VIA DE ACCESO A DIQUE MD | 2022-10-31 → 2022-11-24 (+24d) | 2022-11-03 → 2022-11-26 (+23d) | 4d → 3d |  |
| 02 | **REPOSICIÓN DE ESTRUCTURAS** | 2022-10-26 → 2022-11-21 (+26d) | 2022-11-10 → 2022-12-06 (+26d) |  |  |
| RE.010 | DEMOLICIÓN DE ESTRUCTURAS EXISTENTES | 2022-10-26 → 2022-11-21 (+26d) | 2022-10-29 → 2022-11-24 (+26d) |  | 29d → 24d |
| RE.060 | MONTAJE DE LOSA CONCRETO 1.6mx1.0mx0.20m EN PASE DE AGUA | 2022-10-31 → 2022-11-24 (+24d) | 2022-11-01 → 2022-11-25 (+24d) |  | 5d → 2d |
| RE.020 | REPOSICIÓN DE PASE DE AGUA TUBERÍA HDPE CORRUGADA Ø=24" | 2022-10-30 → 2022-11-25 (+26d) | 2022-11-02 → 2022-11-28 (+26d) |  | 29d → 24d |
| RE.040 | REPOSICIÓN DE PASE DE AGUA TUBERÍA HDPE CORRUGADA Ø=36" | 2022-10-30 → 2022-11-25 (+26d) | 2022-11-02 → 2022-11-28 (+26d) |  | 29d → 24d |
| RE.030 | ESTRUCTURA DE CONCRETO 175 Kg/cm2 DE CABEZAL ENTRADA Y SALIDA DE TUB. HDPE CORRUGADA Ø=24" | 2022-11-03 → 2022-11-29 (+26d) | 2022-11-10 → 2022-12-06 (+26d) |  | 29d → 24d |
| RE.050 | ESTRUCTURA DE CONCRETO 175 Kg/cm2 DE CABEZAL ENTRADA Y SALIDA DE TUB. HDPE CORRUGADA Ø=36" | 2022-11-03 → 2022-11-29 (+26d) | 2022-11-10 → 2022-12-06 (+26d) |  | 29d → 24d |
| 00 | **GENERAL** | 2022-10-26 → 2022-11-21 (+26d) | 2022-12-09 → 2022-12-30 (+21d) |  |  |
| 03 | **PROGRAMA DE CIERRE DE OBRA** | 2022-10-26 → 2022-11-21 (+26d) | 2022-12-09 → 2022-12-30 (+21d) |  |  |
| PCO.010 | RESTAURACIÓN DE ÁREAS DE INSTALACIONES PROVISIONALES | 2022-12-07 → 2022-12-28 (+21d) | 2022-12-09 → 2022-12-30 (+21d) |  |  |
| 2 | **ACONDICIONAMIENTO DE DEPÓSITOS DE MATERIALES EXCEDENTES** | 2022-10-26 → 2022-11-21 (+26d) | 2022-12-01 → 2022-12-24 (+23d) |  |  |
| PCO.020 | RETIRO Y ALMACENAMIENTO DE TOPSOIL DEL DME | 2022-10-26 → 2022-11-21 (+26d) | 2022-10-29 → 2022-11-24 (+26d) |  | 25d → 20d |
| PCO.030 | ACONDICIONAMIENTO DE MATERIAL EN BOTADERO | 2022-11-08 → 2022-12-01 (+23d) | 2022-11-23 → 2022-12-16 (+23d) |  | 16d → 14d |
| PCO.040 | COLOCACIÓN DE CAPA SUPERFICIAL DEL DME | 2022-11-28 → 2022-12-21 (+23d) | 2022-12-01 → 2022-12-24 (+23d) |  | 8d → 6d |
| 14 | **REFUERZO DE RIBERA DEL RIO** | 2022-11-04 → 2022-11-27 (+23d) | 2022-12-06 → 2022-12-27 (+21d) |  |  |
| 5 | **PROTECCIÓN DEL CAUCE CON ENROCADO (A4-PT-PLR-01)-AGUAS ABAJO** | 2022-11-04 → 2022-11-27 (+23d) | 2022-11-11 → 2022-12-04 (+23d) |  |  |
| PLR-01-010 | DESBROCE Y LIMPIEZA EN ZONA NO BOSCOSA | 2022-11-04 → 2022-11-27 (+23d) | 2022-11-04 → 2022-11-27 (+23d) |  | 3d → 1d |
| PLR-01-020 | EXCAVACIÓN EN MATERIAL SUELTO CON EQUIPO | 2022-11-05 → 2022-11-28 (+23d) | 2022-11-06 → 2022-11-29 (+23d) |  | 3d → 1d |
| PLR-01-030 | PERFILADO Y COMPACTACIÓN CON EQUIPO DE FONDO DE EXCAVACIÓN | 2022-11-06 → 2022-11-29 (+23d) | 2022-11-07 → 2022-11-30 (+23d) |  | 3d → 1d |
| PLR-01-040 | TRANSPORTE DE ROCA | 2022-11-06 → 2022-11-29 (+23d) | 2022-11-10 → 2022-12-03 (+23d) |  | 5d → 3d |
| PLR-01-050 | COLOCACIÓN DE ROCA EN CAUCE | 2022-11-07 → 2022-11-30 (+23d) | 2022-11-11 → 2022-12-04 (+23d) |  | 5d → 3d |
| 10 | **PROTECCION DE TALUDES (A4-PT-D-03)** | 2022-11-08 → 2022-12-01 (+23d) | 2022-11-19 → 2022-12-12 (+23d) |  |  |
| D.03.010 | DESBROCE Y LIMPIEZA EN ZONA NO BOSCOSA | 2022-11-08 → 2022-12-01 (+23d) | 2022-11-08 → 2022-12-01 (+23d) |  | 3d → 1d |
| D.03.015 | TRANSPORTE DE MATERIAL EXCEDENTE | 2022-11-08 → 2022-12-01 (+23d) | 2022-11-08 → 2022-12-01 (+23d) |  | 27d → 25d |
| D.03.020 | RELLENO ESTRUCTURAL CON MATERIAL PROPIO EN TALUD EXISTENTE | 2022-11-09 → 2022-12-02 (+23d) | 2022-11-10 → 2022-12-03 (+23d) |  | 3d → 1d |
| D.03.030 | EXCAVACIÓN EN TERRENO NATURAL CON EQUIPO | 2022-11-11 → 2022-12-04 (+23d) | 2022-11-11 → 2022-12-04 (+23d) |  | 3d → 1d |
| D.03.040 | PERFILADO Y COMPACTACIÓN EN ZONA DE CORTE | 2022-11-12 → 2022-12-05 (+23d) | 2022-11-12 → 2022-12-05 (+23d) |  | 3d → 1d |
| D.03.060 | COLOCACIÓN DE GEOTEXTIL NO TEJIDO 400 gr/m2 | 2022-11-13 → 2022-12-06 (+23d) | 2022-11-13 → 2022-12-06 (+23d) |  | 3d → 1d |
| D.03.070 | TRANSPORTE DE ROCA | 2022-11-13 → 2022-12-06 (+23d) | 2022-11-18 → 2022-12-11 (+23d) |  | 3d → 1d |
| D.03.080 | COLOCACIÓN Y ACOMODO DE ROCA EN UÑA DEL DIQUE | 2022-11-14 → 2022-12-07 (+23d) | 2022-11-15 → 2022-12-08 (+23d) |  | 3d → 1d |
| D.03.090 | COLOCACIÓN Y ACOMODO DE ROCA EN TALUD DEL DIQUE | 2022-11-16 → 2022-12-09 (+23d) | 2022-11-19 → 2022-12-12 (+23d) |  | 3d → 1d |
| 1 | **PROTECCION DE TALUDES (A4-PT-I-02)** | 2022-11-13 → 2022-12-06 (+23d) | 2022-11-25 → 2022-12-18 (+23d) |  |  |
| I-02.010 | DESBROCE Y LIMPIEZA EN ZONA NO BOSCOSA | 2022-11-13 → 2022-12-06 (+23d) | 2022-11-13 → 2022-12-06 (+23d) |  | 3d → 1d |
| I-02.020 | TRANSPORTE DE MATERIAL EXCEDENTE | 2022-11-13 → 2022-12-06 (+23d) | 2022-11-13 → 2022-12-06 (+23d) |  | 26d → 24d |
| I-02.030 | RELLENO ESTRUCTURAL CON MATERIAL PROPIO EN TALUD EXISTENTE | 2022-11-14 → 2022-12-07 (+23d) | 2022-11-15 → 2022-12-08 (+23d) |  | 3d → 1d |
| I-02.040 | EXCAVACIÓN EN TERRENO NATURAL CON EQUIPO | 2022-11-16 → 2022-12-09 (+23d) | 2022-11-17 → 2022-12-10 (+23d) |  | 3d → 1d |
| I-02.050 | PERFILADO Y COMPACTACIÓN EN ZONA DE CORTE | 2022-11-17 → 2022-12-10 (+23d) | 2022-11-18 → 2022-12-11 (+23d) |  | 3d → 1d |
| I-02.060 | COLOCACIÓN DE GEOTEXTIL NO TEJIDO 400 gr/m2 | 2022-11-19 → 2022-12-12 (+23d) | 2022-11-20 → 2022-12-13 (+23d) |  | 3d → 1d |
| I-02.070 | TRANSPORTE DE ROCA | 2022-11-19 → 2022-12-12 (+23d) | 2022-11-24 → 2022-12-17 (+23d) |  | 3d → 1d |
| I-02.080 | COLOCACIÓN Y ACOMODO DE ROCA EN UÑA DEL DIQUE | 2022-11-20 → 2022-12-13 (+23d) | 2022-11-21 → 2022-12-14 (+23d) |  | 3d → 1d |
| I-02.090 | COLOCACIÓN Y ACOMODO DE ROCA EN TALUD DEL DIQUE | 2022-11-22 → 2022-12-15 (+23d) | 2022-11-25 → 2022-12-18 (+23d) |  | 3d → 1d |
| 2 | **PROTECCION DE TALUDES (A4-PT-I-03)** | 2022-11-19 → 2022-12-12 (+23d) | 2022-12-03 → 2022-12-26 (+23d) |  |  |
| I-03.010 | DESBROCE Y LIMPIEZA EN ZONA NO BOSCOSA | 2022-11-19 → 2022-12-12 (+23d) | 2022-11-19 → 2022-12-12 (+23d) |  | 4d → 2d |
| I-03.012 | TRANSPORTE DE MATERIAL EXCEDENTE | 2022-11-19 → 2022-12-12 (+23d) | 2022-11-19 → 2022-12-12 (+23d) |  | 20d → 18d |
| I-03.020 | RELLENO ESTRUCTURAL CON MATERIAL PROPIO EN TALUD EXISTENTE | 2022-11-20 → 2022-12-13 (+23d) | 2022-11-21 → 2022-12-14 (+23d) |  | 4d → 2d |
| I-03.030 | EXCAVACIÓN EN TERRENO NATURAL CON EQUIPO | 2022-11-22 → 2022-12-15 (+23d) | 2022-11-22 → 2022-12-15 (+23d) |  | 4d → 2d |
| I-03.040 | PERFILADO Y COMPACTACIÓN EN ZONA DE CORTE | 2022-11-23 → 2022-12-16 (+23d) | 2022-11-23 → 2022-12-16 (+23d) |  | 4d → 2d |

| ID | Task | Start | Finish | Duration | Total float |
| --- | --- | --- | --- | --- | --- |
| I-03.060 | COLOCACIÓN DE GEOTEXTIL NO TEJIDO 400 gr/m2 | 2022-11-24 → 2022-12-17 (+23d) | 2022-11-25 → 2022-12-18 (+23d) |  | 4d → 2d |
| I-03.070 | TRANSPORTE DE ROCA | 2022-11-24 → 2022-12-17 (+23d) | 2022-12-01 → 2022-12-24 (+23d) |  | 4d → 2d |
| I-03.080 | COLOCACIÓN Y ACOMODO DE ROCA EN UÑA DEL DIQUE | 2022-11-26 → 2022-12-19 (+23d) | 2022-11-29 → 2022-12-22 (+23d) |  | 3d → 1d |
| I-03.090 | COLOCACIÓN Y ACOMODO DE ROCA EN TALUD DEL DIQUE | 2022-11-30 → 2022-12-23 (+23d) | 2022-12-03 → 2022-12-26 (+23d) |  | 3d → 1d |
| 3 | **PROTECCIÓN DEL CAUCE CON ENROCADO (A4-PT-PLR-01)-AGUAS ARRIBA** | 2022-11-04 → 2022-11-27 (+23d) | 2022-11-13 → 2022-12-06 (+23d) |  |  |
| PLR-01-060 | DESBROCE Y LIMPIEZA EN ZONA NO BOSCOSA | 2022-11-04 → 2022-11-27 (+23d) | 2022-11-05 → 2022-11-28 (+23d) |  |  |
| PLR-01-070 | EXCAVACIÓN EN MATERIAL SUELTO CON EQUIPO | 2022-11-06 → 2022-11-29 (+23d) | 2022-11-08 → 2022-12-01 (+23d) |  |  |
| PLR-01-080 | PERFILADO Y COMPACTACIÓN CON EQUIPO DE FONDO DE EXCAVACIÓN | 2022-11-08 → 2022-12-01 (+23d) | 2022-11-09 → 2022-12-02 (+23d) |  |  |
| PLR-01-090 | TRANSPORTE DE ROCA | 2022-11-08 → 2022-12-01 (+23d) | 2022-11-12 → 2022-12-05 (+23d) |  |  |
| PLR-01-100 | COLOCACIÓN DE ROCA EN CAUCE | 2022-11-09 → 2022-12-02 (+23d) | 2022-11-13 → 2022-12-06 (+23d) |  |  |
| 9 | **DIQUE DE TIERRA COMPACTADA (A4-PT- D-04)** | 2022-11-10 → 2022-12-03 (+23d) | 2022-11-24 → 2022-12-17 (+23d) |  |  |
| D.04.010 | DESBROCE Y LIMPIEZA EN ZONA NO BOSCOSA | 2022-11-10 → 2022-12-03 (+23d) | 2022-11-11 → 2022-12-04 (+23d) |  |  |
| D.04.020 | TRANSPORTE DE MATERIAL EXCEDENTE | 2022-11-10 → 2022-12-03 (+23d) | 2022-11-11 → 2022-12-04 (+23d) |  | 28d → 26d |
| D.04.030 | CONFORMACION DE CUERPO DE DIQUE | 2022-11-12 → 2022-12-05 (+23d) | 2022-11-14 → 2022-12-07 (+23d) |  |  |
| D.04.040 | EXCAVACIÓN EN TERRENO NATURAL CON EQUIPO | 2022-11-14 → 2022-12-07 (+23d) | 2022-11-15 → 2022-12-08 (+23d) |  |  |
| D.04.050 | PERFILADO Y COMPACTACIÓN EN ZONA DE CORTE | 2022-11-15 → 2022-12-08 (+23d) | 2022-11-16 → 2022-12-09 (+23d) |  |  |
| D.04.060 | COLOCACIÓN DE GEOTEXTIL NO TEJIDO 400 gr/m2 | 2022-11-17 → 2022-12-10 (+23d) | 2022-11-18 → 2022-12-11 (+23d) |  |  |
| D.04.070 | TRANSPORTE DE ROCA | 2022-11-17 → 2022-12-10 (+23d) | 2022-11-21 → 2022-12-14 (+23d) |  |  |
| D.04.080 | COLOCACIÓN Y ACOMODO DE ROCA EN UÑA DEL DIQUE | 2022-11-18 → 2022-12-11 (+23d) | 2022-11-19 → 2022-12-12 (+23d) |  |  |
| D.04.090 | COLOCACIÓN Y ACOMODO DE ROCA EN TALUD DEL DIQUE | 2022-11-20 → 2022-12-13 (+23d) | 2022-11-23 → 2022-12-16 (+23d) |  |  |
| D.04.100 | CONFORMACIÓN DE MATERIAL GRANULAR EN CORONA DE DIQUE (e=0.30 m) | 2022-11-24 → 2022-12-17 (+23d) | 2022-11-24 → 2022-12-17 (+23d) |  | 15d → 13d |
| 4 | **DIQUE DE TIERRA COMPACTADA (A4-PT- D-05)** | 2022-11-16 → 2022-12-09 (+23d) | 2022-12-06 → 2022-12-27 (+21d) |  |  |
| D.05.010 | DESBROCE Y LIMPIEZA EN ZONA NO BOSCOSA | 2022-11-16 → 2022-12-09 (+23d) | 2022-11-17 → 2022-12-10 (+23d) |  |  |
| D.05.020 | TRANSPORTE DE MATERIAL EXCEDENTE | 2022-11-16 → 2022-12-09 (+23d) | 2022-11-17 → 2022-12-10 (+23d) |  | 18d → 16d |
| D.05.030 | CONFORMACION DE CUERPO DE DIQUE | 2022-11-18 → 2022-12-11 (+23d) | 2022-11-22 → 2022-12-15 (+23d) |  |  |
| D.05.040 | EXCAVACIÓN EN TERRENO NATURAL CON EQUIPO | 2022-11-22 → 2022-12-15 (+23d) | 2022-11-23 → 2022-12-16 (+23d) |  |  |
| D.05.050 | PERFILADO Y COMPACTACIÓN EN ZONA DE CORTE | 2022-11-22 → 2022-12-15 (+23d) | 2022-11-24 → 2022-12-17 (+23d) |  |  |
| D.05.070 | COLOCACIÓN DE GEOTEXTIL NO TEJIDO 400 gr/m2 | 2022-11-23 → 2022-12-16 (+23d) | 2022-11-25 → 2022-12-18 (+23d) |  |  |
| D.05.080 | TRANSPORTE DE ROCA | 2022-11-23 → 2022-12-16 (+23d) | 2022-12-03 → 2022-12-24 (+21d) | 11d → 9d |  |
| D.05.090 | COLOCACIÓN Y ACOMODO DE ROCA EN UÑA DEL DIQUE | 2022-11-24 → 2022-12-17 (+23d) | 2022-11-27 → 2022-12-20 (+23d) |  |  |
| D.05.100 | COLOCACIÓN Y ACOMODO DE ROCA EN TALUD DEL DIQUE | 2022-11-28 → 2022-12-21 (+23d) | 2022-12-04 → 2022-12-25 (+21d) | 7d → 5d |  |
| D.05.110 | CONFORMACIÓN DE MATERIAL GRANULAR EN CORONA DE DIQUE (e=0.30 m) | 2022-12-05 → 2022-12-26 (+21d) | 2022-12-06 → 2022-12-27 (+21d) |  |  |
| 7 | **REPOSICIÓN DE CAMINO DE ACCESO (A4-RC-1)** | 2022-11-25 → 2022-12-18 (+23d) | 2022-11-30 → 2022-12-23 (+23d) |  |  |
| RC.010 | DESBROCE Y LIMPIEZA EN ZONA NO BOSCOSA | 2022-11-25 → 2022-12-18 (+23d) | 2022-11-25 → 2022-12-18 (+23d) |  | 6d → 4d |
| RC.020 | EXCAVACIÓN EN MATERIAL SUELTO CON EQUIPO | 2022-11-26 → 2022-12-19 (+23d) | 2022-11-27 → 2022-12-20 (+23d) |  | 6d → 4d |
| RC.030 | PERFILADO Y COMPACTACIÓN EN ZONA DE CORTE | 2022-11-28 → 2022-12-21 (+23d) | 2022-11-29 → 2022-12-22 (+23d) |  | 6d → 4d |
| RC.040 | MATERIAL AFIRMADO e=25 cm | 2022-11-30 → 2022-12-23 (+23d) | 2022-11-30 → 2022-12-23 (+23d) |  | 6d → 4d |
